# BEDs_schedule_2012

Schedule from MS Project, 2013-07-18 to 2014-11-10.

## Calendars

- Standard: Mon-Fri 08:00-12:00, 13:00-17:00; Sat-Sun off.

## Schedule

| ID | WBS | Task | Type | Duration | Start | Finish | Predecessors | Total slack |
| --- | --- | --- | --- | --- | --- | --- | --- | --- |
| 1 | 1 | **Software** |  | 37d | 2014-01-10 | 2014-03-03 |  | 0d |
| 2 | 1.1 | Data Analysis | manual | 26d | 2014-01-10 | 2014-02-14 |  |  |
| 3 | 1.2 | Upgrades | manual | 12d | 2014-02-14 | 2014-03-03 | 14 |  |
| 4 | 2 | **Shore Side** |  | 81d | 2014-01-08 | 2014-04-30 |  | 0d |
| 5 | 2.1 | Matlab review scripts | manual | 36d | 2014-03-10 | 2014-04-28 |  |  |
| 6 | 2.2 | Poster Prep | manual | 23d | 2014-01-08 | 2014-02-07 |  |  |
| 7 | 2.3 | Poster Presentation ASLO | milestone, manual | 0d | 2014-02-27 | 2014-02-27 |  |  |
| 8 | 2.4 | Animation STOQs Integration | manual | 11d | 2014-03-10 | 2014-03-24 |  |  |
| 9 | 2.5 | **Wave Glider** |  | 68d | 2014-01-27 | 2014-04-30 |  | 0d |
| 10 | 2.5.1 | Fair xducer | manual | 28d | 2014-03-24 | 2014-04-30 |  |  |
| 11 | 2.5.2 | SV3 Integration | manual | 21d | 2014-01-27 | 2014-02-24 |  |  |
| 12 | 3 | **Electrical** |  | 16d? | 2014-01-13 | 2014-02-04 |  | 0d |
| 13 | 3.1 | BED #2 prep | manual | 1d? | 2014-01-13 | 2014-01-13 |  |  |
| 14 | 3.2 | Order Batteries | milestone, manual | 0d | 2014-02-04 | 2014-02-04 |  |  |
| 15 | 3.3 | Fix WG electrical wiring | manual | 16d | 2014-01-13 | 2014-02-03 |  |  |
| 16 | 4 | **Mechanical** |  | 55d | 2014-01-13 | 2014-03-28 |  | 0d |
| 17 | 4.1 | Pressure sensor upgrade | manual | 31d | 2014-01-13 | 2014-02-24 |  |  |
| 18 | 4.2 | Pressure sensor cal | manual | 24d | 2014-02-25 | 2014-03-28 | 17 |  |
| 19 | 4.3 | Integrate acoustic pole | milestone, manual | 0d | 2014-01-16 | 2014-01-16 |  |  |
| 20 | 5 | **Systems** |  | 215d? | 2014-01-13 | 2014-11-10 |  | 0d |
| 21 | 5.1 | Calibrate USBL | manual | 4d | 2014-01-16 | 2014-01-21 |  |  |
| 22 | 5.2 | RTC calibration | manual | 35d | 2014-01-13 | 2014-02-28 | 14 |  |
| 23 | 5.3 | Carson cruise | milestone, manual | 0d | 2014-03-04 | 2014-03-04 |  |  |
| 24 | 5.4 | Carson cruise | milestone, manual | 0d | 2014-11-10 | 2014-11-10 |  |  |
| 25 | 5.5 | CDR | milestone, manual | 0d | 2014-02-11 | 2014-02-11 |  |  |
| 26 | 5.6 | Construct 7 BEDs | manual | 1d? | 2014-01-13 | 2014-01-13 |  |  |

| ID | WBS | Task | Type | Duration | Start | Finish | Total slack |
| --- | --- | --- | --- | --- | --- | --- | --- |
| 27 | 6 | **Operations** |  | 343d | 2013-07-18 | 2014-11-10 | 0d |
| 28 | 6.1 | BED #2 Deployment | manual | 106d | 2013-07-18 | 2013-12-12 |  |
| 29 | 6.2 | BED/Monument Deployment | manual | 238d | 2013-12-12 | 2014-11-10 |  |
